# Hausbau

Schedule from MS Project MPX, 2000-08-10 to 2001-06-29, A marks actual dates.

## Calendars

- Standard: Mon-Fri 08:00-12:00, 13:00-17:00; Sat-Sun off.

## Schedule

| ID | WBS | Task | Type | Duration | Start | Finish | Predecessors | Complete | Total slack | Free slack | Constraint | Text1 |
| --- | --- | --- | --- | --- | --- | --- | --- | --- | --- | --- | --- | --- |
| 1 | 1 | **Planning and building permission** |  | 42d | 2000-08-10 A | 2000-10-06 A |  | 100% | 0d |  | as late as possible | 2 |
| 2 | 1.1 | Application for building |  | 8w | 2000-08-10 A | 2000-10-04 A | 9 | 100% | 0w |  | as late as possible | 2 |
| 3 | 1.2 | Permission |  | 2d | 2000-10-05 A | 2000-10-06 A | 2 | 100% | 0d |  | as late as possible | 2 |
| 4 | 2 | **Financing** |  | 30d | 2000-10-09 A | 2000-11-17 |  | 15% | 0d |  | as late as possible | 3 |
| 5 | 2.1 | Financial plan |  | 3w | 2000-10-09 A | 2000-10-27 | 3 | 30% | 0w |  | as late as possible | 3 |
| 6 | 2.2 | Complition |  | 3w | 2000-10-30 | 2000-11-17 | 5 |  | 0w |  | as late as possible | 3 |
| 7 | 2.3 | Paying out | milestone | 0d | 2000-11-17 | 2000-11-17 | 6 |  | 160d |  |  | 3 |
| 8 | 3 | **Planning of the building** |  | 175d | 2000-10-30 A | 2001-06-29 |  | 50% | 0d |  | as late as possible | 1 |
| 9 | 3.1 | Design selection |  | 4w | 2001-06-04 A | 2001-06-29 A |  | 100% | 0w |  | as late as possible | 1 |
| 10 | 3.2 | Building plan |  | 4w | 2000-10-30 | 2000-11-24 | 5, 3 |  | 12w | 0w |  | 1 |
| 11 | 4 | **Prepare Site** |  | 160d | 2000-11-20 | 2001-06-29 |  |  | 0d |  | as late as possible | 4 |
| 12 | 4.1 | Lay Foundations/Underground Pipework |  | 3w | 2000-11-20 | 2000-12-08 | 6 |  | 0w |  | as late as possible | 4 |
| 13 | 4.2 | **Exterior grounds** |  | 95d | 2001-02-19 | 2001-06-29 |  |  | 60d | 0d | as late as possible | 4 |
| 14 | 4.2.1 | Designing exterior grounds |  | 3w | 2001-02-19 | 2001-03-09 | 10 |  | 12w | 0w | as late as possible | 4 |
| 15 | 4.2.2 | Building exterior grounds |  | 16w | 2001-03-12 | 2001-06-29 | 14 |  | 12w | 0w | as late as possible | 4 |
| 16 | 5 | **Shell** |  | 145d | 2000-12-11 | 2001-06-29 |  |  | 0d |  | as late as possible | 5 |
| 17 | 5.1 | Basement |  | 9w | 2000-12-11 | 2001-02-09 | 12 |  | 0w |  | as late as possible | 5 |
| 18 | 5.2 | Ground floor |  | 8w | 2001-02-12 | 2001-04-06 | 17 |  | 0w |  | as late as possible | 5 |
| 19 | 5.3 | Top floor |  | 6w | 2001-04-09 | 2001-05-18 | 18 |  | 0w |  | as late as possible | 5 |
| 20 | 5.4 | Topping-out ceremony | milestone | 0d | 2001-05-21 | 2001-05-21 | 19 |  | 0d |  | as late as possible | 5 |
| 21 | 5.5 | Interior design |  | 6w | 2001-05-21 | 2001-06-29 | 20 |  | 0w |  | as late as possible | 5 |
| 22 | 5.6 | Handing over the keys | milestone | 0d | 2001-06-29 | 2001-06-29 | 21, 20, 15 |  | 0d |  | as late as possible | 5 |
