# TA_DELIVERY_20001219

Schedule from MS Project MPX, 1998-02-02 to 2001-10-12, A marks actual dates.
Austria Telecommunication / Kapsch AG

## Calendars

- Standard: Mon-Fri 08:00-12:00, 13:00-17:00; Sat-Sun off. Exceptions (off unless hours are given): 1999-12-24, 1999-12-27 to 1999-12-31, 2000-01-03 to 2000-01-07, 2000-12-25 to 2000-12-29, 2001-01-01 to 2001-01-05.

## Schedule

| ID | WBS | Task | Duration | Start | Finish | Predecessors | Complete | Total slack | Free slack | Constraint | Text1 |
| --- | --- | --- | --- | --- | --- | --- | --- | --- | --- | --- | --- |
| 1 | 1 | **Projekt CAMS** | 944t | 1998-02-02 A | 2001-10-12 |  | 86% | 0t |  | so früh wie möglich |  |
| 2 | 1.1 | **Vorprojektphase** | 300t | 1998-02-02 A | 1999-03-27 A |  | 100% | 0t |  | so früh wie möglich | Gberwid |
| 3 | 1.1.1 | Kundenspezifikation TA | 130t | 1998-02-02 A | 1998-07-31 A |  | 100% | 0t |  | ende nicht früher als 1998-07-31 | Wscherer |
| 4 | 1.1.2 | Produktauswahl | 190t | 1998-07-06 A | 1999-03-27 A |  | 100% | 0t |  | ende nicht früher als 1999-03-27 | Gberwid |
| 5 | 1.2 | **Projektmanagement** | 641t | 1999-04-01 A | 2001-10-12 |  | 84% | 0t |  | so früh wie möglich | Wscherer |
| 6 | 1.2.1 | Produktauswahl erfolgt | 0t | 1999-04-01 A | 1999-04-01 A |  | 100% | 0t |  | so früh wie möglich | Gberwid |
| 7 | 1.2.2 | **Projektstart** | 42t | 1999-04-01 A | 1999-05-28 A |  | 100% | 0t |  | so früh wie möglich | Wscherer |
| 8 | 1.2.2.1 | Projektteam zusammenstellen | 14t | 1999-04-01 A | 1999-04-20 A |  | 100% | 0t |  | so früh wie möglich | Wscherer |
| 9 | 1.2.2.2 | Projektorganisation definieren | 14t | 1999-04-21 A | 1999-05-10 A | 8 | 100% | 0t |  | so früh wie möglich | Wscherer |
| 10 | 1.2.2.3 | Projektkommunikation definieren | 14t | 1999-05-11 A | 1999-05-28 A | 9 | 100% | 0t |  | so früh wie möglich | Wscherer |
| 11 | 1.2.3 | **Projektorganisation** | 150t | 1999-05-28 A | 2000-01-10 A |  | 100% | 0t |  | so früh wie möglich | Wscherer |
| 12 | 1.2.3.1 | Project Freeze | 149t | 1999-05-28 A | 1999-12-22 A |  | 100% | 0t |  | ende nicht früher als 1999-12-22 | Ddungl |
| 13 | 1.2.3.2 | Kundenbestellung erfolgt | 0t | 1999-12-22 A | 1999-12-22 A |  | 100% | 0t |  | anfang nicht früher als 1999-12-22 | Mpaula |
| 14 | 1.2.3.3 | **Project Restart** | 4t | 1999-12-20 A | 2000-01-10 A |  | 100% | 0t |  | so früh wie möglich | Wscherer |
| 15 | 1.2.3.3.1 | Projektmanagerwechsel | 3t | 1999-12-20 A | 1999-12-22 A |  | 100% | 0t |  | anfang nicht früher als 1999-12-20 | Ddungl |
| 16 | 1.2.3.3.2 | externe Kommunikation definieren | 2t | 1999-12-22 A | 1999-12-23 A |  | 100% | 0t |  | ende nicht früher als 1999-12-23 | Wscherer |
| 17 | 1.2.3.3.3 | Projekt mit AOSA,ICL,TA neu gestartet | 0t | 2000-01-10 A | 2000-01-10 A |  | 100% | 0t |  | anfang nicht früher als 2000-01-10 | Wscherer |
| 18 | 1.2.4 | Projektcontrolling | 450t | 2000-01-10 A | 2001-10-12 |  | 80% | 0t |  | anfang nicht früher als 2000-01-10 | Wscherer |
| 19 | 1.2.5 | **Projektabschluss** | 20t | 2001-09-03 | 2001-09-28 |  |  | 10t |  | so früh wie möglich | Wscherer |
| 20 | 1.2.5.1 | interner Projektabschluss | 10t | 2001-09-03 | 2001-09-14 |  |  | 10t | 0t | anfang nicht früher als 2001-09-03 | Wscherer |
| 21 | 1.2.5.2 | Kundenprojektabschluss | 10t | 2001-09-17 | 2001-09-28 | 20 |  | 10t | 0t | so früh wie möglich | Wscherer |
| 22 | 1.2.5.3 | Projekt abgschlossen | 0t | 2001-09-28 | 2001-09-28 | 21, 117 |  | 10t |  | so früh wie möglich | Ddungl |
| 23 | 1.2.6 | **Spezifikation** | 42t | 1999-04-01 A | 1999-05-28 A |  | 100% | 0t |  | so früh wie möglich | Wscherer |
| 24 | 1.2.6.1 | Customer Requirements Specification ICL | 42t | 1999-04-01 A | 1999-05-28 A |  | 100% | 0t |  | anfang nicht früher als 1999-04-01 | Wscherer |

| ID | WBS | Task | Duration | Start | Finish | Predecessors | Complete | Total slack | Constraint | Text1 |
| --- | --- | --- | --- | --- | --- | --- | --- | --- | --- | --- |
| 25 | 1.3 | **Vertrieb&Commercial** | 652t | 1999-03-03 A | 2001-09-28 |  | 79% | 10t | so früh wie möglich | Mpaula |
| 26 | 1.3.1 | Vertriebsabwicklung | 652t | 1999-03-03 A | 2001-09-28 |  | 80% | 10t | ende nicht früher als 2001-09-28 | Mpaula |
| 27 | 1.3.2 | **Vertragsgestaltung** | 484t | 1999-04-05 A | 2001-03-09 |  | 77% | 155t | so früh wie möglich | Hkridl |
| 28 | 1.3.2.1 | Supply-Vertrag ICL | 20t | 1999-05-03 A | 1999-05-28 A |  | 100% | 0t | ende nicht früher als 1999-05-28 | Hkridl |
| 29 | 1.3.2.2 | Kooperationsvertrag AOSA | 123t | 1999-04-05 A | 1999-09-22 |  | 50% | 516t | anfang nicht früher als 1999-04-05 | Mpaula |
| 30 | 1.3.2.3 | Support-Contract ICL | 125t | 2000-09-04 A | 2001-03-09 A |  | 100% | 0t | anfang nicht früher als 2000-09-04 | Dkoller |
| 31 | 1.4 | **Design** | 425t | 2000-01-10 A | 2001-09-07 | 14 | 91% | 25t | so früh wie möglich | Cbrandner |
| 32 | 1.4.1 | Basis-Architektur | 30t | 2000-01-10 A | 2000-02-18 A |  | 100% | 0t | so früh wie möglich | Gplank |
| 33 | 1.4.2 | **Collection&Transfer** | 129t | 2000-01-11 A | 2000-07-07 A |  | 100% | 0t | so früh wie möglich | Cprengel |
| 34 | 1.4.2.1 | Interface-Spezifikation | 69t | 2000-01-11 A | 2000-04-14 A |  | 100% | 0t | ende nicht früher als 2000-04-14 | Cprengel |
| 35 | 1.4.2.2 | CAMSTOOLS | 60t | 2000-04-17 A | 2000-07-07 A |  | 100% | 0t | ende nicht früher als 2000-07-07 | Cprengel |
| 36 | 1.4.3 | **Formate&Conversion** | 241t | 2000-01-10 A | 2000-12-11 A |  | 100% | 0t | so früh wie möglich | Fkashofer |
| 37 | 1.4.3.1 | Conversion AR36 | 151t | 2000-01-10 A | 2000-08-07 A |  | 100% | 0t | anfang nicht früher als 2000-01-10 | Fkashofer |
| 38 | 1.4.3.2 | Conversion AR38 | 30t | 2000-08-08 A | 2000-09-18 A | 37 | 100% | 0t | anfang nicht früher als 1999-12-20 | Fkashofer |
| 39 | 1.4.3.3 | Conversion Abgleich mit RDNB | 30t | 2000-09-19 A | 2000-10-30 A | 38 | 100% | 0t | so früh wie möglich | Fkashofer |
| 40 | 1.4.3.4 | Conversion AR40 | 30t | 2000-10-31 A | 2000-12-11 A | 39 | 100% | 0t | so früh wie möglich | Fkashofer |
| 41 | 1.4.4 | **admin.Applikationen** | 80t | 2000-01-10 A | 2000-04-28 A |  | 100% | 0t | so früh wie möglich | Cbrandner |
| 42 | 1.4.4.1 | Reports | 80t | 2000-01-10 A | 2000-04-28 A |  | 100% | 0t | so früh wie möglich | Rskarbal |
| 43 | 1.4.4.2 | Data Query | 80t | 2000-01-10 A | 2000-04-28 A |  | 100% | 0t | so früh wie möglich | Gpolenik |
| 44 | 1.4.5 | Übergabe AT-Development an ICL | 0t | 2000-08-07 A | 2000-08-07 A | 37, 43 | 100% | 0t | so früh wie möglich | Cbrandner |
| 45 | 1.4.6 | **Einbindung OAM-Netz** | 1t | 2000-01-10 | 2000-01-10 |  |  | 449t | so früh wie möglich | Cprengel |
| 46 | 1.4.6.1 | Alarmierung | 1t | 2000-01-10 | 2000-01-10 |  |  | 449t | so früh wie möglich | Cprengel |
| 47 | 1.4.6.2 | Table-Import | 1t | 2000-01-10 | 2000-01-10 |  |  | 449t | so früh wie möglich | Cprengel |
| 48 | 1.4.7 | ZNK-Funktionen | 23W | 2000-11-06 A | 2001-04-27 A |  | 100% | 0W | anfang nicht früher als 2000-11-06 | Cbrandner |
| 49 | 1.4.8 | Configuration Management | 424t | 2000-01-10 A | 2001-09-06 |  | 95% | 26t | so früh wie möglich | Rskarbal |
| 50 | 1.4.9 | Design-Dokumentation | 424t | 2000-01-10 A | 2001-09-06 |  | 90% | 26t | so früh wie möglich | Gpolenik |

| ID | WBS | Task | Duration | Start | Finish | Predecessors | Complete | Total slack | Free slack | Constraint | Text1 |
| --- | --- | --- | --- | --- | --- | --- | --- | --- | --- | --- | --- |
| 51 | 1.4.10 | **Performance-Verbesserung** | 45t | 2001-07-09 A | 2001-09-07 |  | 5% | 25t |  | so früh wie möglich | Cbrandner |
| 52 | 1.4.10.1 | Beauftragung ICL | 1t | 2001-07-09 A | 2001-07-09 A |  | 100% | 0t |  | anfang nicht früher als 2001-07-09 | Cbrandner |
| 53 | 1.4.10.2 | Implementierungs-Workshop mit ICL | 4t | 2001-07-31 | 2001-08-03 |  |  | 25t | 0t | anfang nicht früher als 2001-07-31 | Fkashofer |
| 54 | 1.4.10.3 | Beta-Release von ICL an AOSA/AT | 0t | 2001-08-07 A | 2001-08-07 A |  | 100% | 0t |  | anfang nicht früher als 2001-08-07 | ICL |
| 55 | 1.4.10.4 | Final Delivery von ICL an AOSA/AT | 0t | 2001-08-17 A | 2001-08-17 A |  | 100% | 0t |  | anfang nicht früher als 2001-08-17 | ICL |
| 56 | 1.4.10.5 | Acceptance Test bei AOSA/AT | 2W | 2001-08-17 A | 2001-08-30 | 55 | 10% | 6,2W | 0W | so früh wie möglich | Fkashofer |
| 57 | 1.4.10.6 | Acceptance | 0t | 2001-08-30 | 2001-08-30 | 56 |  | 31t |  | so früh wie möglich | Fkashofer |
| 58 | 1.4.10.7 | Implementierung im CAMS-Project-Code | 5W | 2001-08-06 | 2001-09-07 | 53 |  | 5W |  | so früh wie möglich | Fkashofer |
| 59 | 1.4.11 | Bugfixing CAMS / AUST | 65t | 2001-06-04 A | 2001-08-31 |  | 40% | 30t |  | ende nicht früher als 2001-08-31 | Cbrandner |
| 60 | 1.5 | **Test&Abnahme** | 335t | 2000-06-05 A | 2001-09-28 |  | 89% | 10t |  | so früh wie möglich | Gbauer |
| 61 | 1.5.1 | Schnittstellen | 66t | 2000-08-07 A | 2000-11-06 A |  | 100% | 0t |  | anfang nicht früher als 2000-08-07 | Jprober |
| 62 | 1.5.2 | **Conversion-Test** | 111t | 2000-08-08 A | 2001-01-23 A |  | 100% | 0t |  | so früh wie möglich | Ebergmann |
| 63 | 1.5.2.1 | Conversion Test AR36 | 10t | 2000-08-08 A | 2000-08-21 A | 37 | 100% | 0t |  | so früh wie möglich | Ebergmann |
| 64 | 1.5.2.2 | Conversion Übergabe an ICL | 0t | 2000-08-21 A | 2000-08-21 A | 63 | 100% | 0t |  | so früh wie möglich | Ebergmann |
| 65 | 1.5.2.3 | Conversion Test AR38 | 1t | 2000-09-19 A | 2000-09-19 A | 38 | 100% | 0t |  | so früh wie möglich | Ebergmann |
| 66 | 1.5.2.4 | Conversion Test AR40 | 20t | 2000-12-13 A | 2001-01-23 A | 40 | 100% | 0t |  | anfang nicht früher als 2000-12-13 | Ebergmann |
| 67 | 1.5.3 | admin.&Control-Funktionen | 66t | 2000-08-07 A | 2000-11-06 A |  | 100% | 0t |  | ende nicht früher als 2000-11-06 | Jmandl |
| 68 | 1.5.4 | **Abnahme ICL** | 31t | 2000-09-25 A | 2000-11-06 A |  | 100% | 0t |  | so früh wie möglich | Gbauer |
| 69 | 1.5.4.1 | Basisversion von ICL bereitgestellt | 0t | 2000-09-25 A | 2000-09-25 A |  | 100% | 0t |  | anfang nicht früher als 2000-09-25 | ICL |
| 70 | 1.5.4.2 | Acceptance Test ICL/AT/AOSA | 31t | 2000-09-25 A | 2000-11-06 A | 69 | 100% | 0t |  | so früh wie möglich | Gbauer |
| 71 | 1.5.4.3 | Basisversion von ICL abgenommen | 0t | 2000-11-06 A | 2000-11-06 A | 70 | 100% | 0t |  | so früh wie möglich | Gbauer |
| 72 | 1.5.5 | Test-Support AOSA | 255t | 2000-09-25 A | 2001-09-28 |  | 80% | 10t |  | ende nicht früher als 2001-09-28 | Gbauer |
| 73 | 1.5.6 | **Demobetrieb** | 144t | 2000-06-05 A | 2000-12-21 A |  | 100% | 0t |  | so früh wie möglich | Gbauer |
| 74 | 1.5.6.1 | Betaversion von ICL bereitgestellt | 1t | 2000-06-05 A | 2000-06-05 A |  | 100% | 0t |  | anfang nicht früher als 2000-06-05 | ICL |
| 75 | 1.5.6.2 | Betaversion installieren auf Standort ZSB | 5t | 2000-06-06 A | 2000-06-12 A | 74 | 100% | 0t |  | so früh wie möglich | Alinhart |
| 76 | 1.5.6.3 | Demobetrieb mit TA | 138t | 2000-06-13 A | 2000-12-21 A | 75 | 100% | 0t |  | so früh wie möglich | Gbauer |

| ID | WBS | Task | Duration | Start | Finish | Predecessors | Complete | Total slack | Constraint | Text1 |
| --- | --- | --- | --- | --- | --- | --- | --- | --- | --- | --- |
| 77 | 1.5.7 | **Abnahmephase 1** | 192t | 2000-12-21 A | 2001-09-28 |  | 85% | 10t | so früh wie möglich | Gbauer |
| 78 | 1.5.7.1 | Abnahmebetreuung | 192t | 2000-12-21 A | 2001-09-28 |  | 80% | 10t | ende nicht früher als 2001-09-28 | Gbauer |
| 79 | 1.5.7.2 | Abnahme RDNV APS14 | 17t | 2001-02-06 A | 2001-02-28 A |  | 100% | 0t | anfang nicht früher als 2001-02-06 | AOSA |
| 80 | 1.5.7.3 | Abnahme CAMS APS14 (Trunk) | 11t | 2001-03-01 A | 2001-03-15 A |  | 100% | 0t | ende nicht früher als 2001-03-15 | AOSA |
| 81 | 1.5.7.4 | Abnahme CAMS AR40.0 | 99t | 2001-02-26 A | 2001-07-12 |  | 90% | 66t | anfang nicht früher als 2001-02-26 | Ebergmann |
| 82 | 1.5.8 | **Abnahmephase 2** | 90t | 2001-03-12 A | 2001-07-13 |  | 93% | 0t | so früh wie möglich | Gbauer |
| 83 | 1.5.8.1 | Abnahme CAMS APS13 POTS | 15t | 2001-03-26 A | 2001-04-13 A |  | 100% | 0t | ende nicht früher als 2001-04-13 | AOSA |
| 84 | 1.5.8.2 | Abnahme RDNB AR40.1 | 15t | 2001-03-12 A | 2001-03-30 A |  | 100% | 0t | ende nicht früher als 2001-03-30 | Ebergmann |
| 85 | 1.5.8.3 | Abnahme CAMS APS14 POTS | 64t | 2001-04-17 A | 2001-07-13 |  | 90% | 0t | muss anfangen am 2001-04-17 | AOSA |
| 87 | 1.6 | **Training&Dokumentation** | 15t | 2001-04-30 A | 2001-05-18 A |  | 100% | 0t | so früh wie möglich | Hnemeth |
| 88 | 1.6.1 | **Schulung** | 15t | 2001-04-30 A | 2001-05-18 A |  | 100% | 0t | so früh wie möglich | Hnemeth |
| 89 | 1.6.1.1 | Session 1 | 1W | 2001-04-30 A | 2001-05-04 A |  | 100% | 0W | anfang nicht früher als 2001-04-30 | Tmikulka |
| 90 | 1.6.1.2 | Session 2 | 1W | 2001-05-07 A | 2001-05-11 A | 89 | 100% | 0W | so früh wie möglich | Tmikulka |
| 91 | 1.6.1.3 | Session 3 | 1W | 2001-05-14 A | 2001-05-18 A | 90 | 100% | 0W | so früh wie möglich | Tmikulka |
| 93 | 1.7 | **Rollout&Testbetrieb** | 192t | 2000-12-21 A | 2001-09-28 |  | 56% | 10t | so früh wie möglich | Mbenes |
| 94 | 1.7.1 | **Phase 1a** | 23t | 2000-12-21 A | 2001-02-05 |  | 99% | 179t | so früh wie möglich | Gbauer |
| 95 | 1.7.1.1 | Testbetrieb 1a Beginn | 2t | 2000-12-21 A | 2000-12-22 A |  | 100% | 0t | ende nicht früher als 2000-12-22 | Gbauer |
| 96 | 1.7.1.2 | Beginn Echtbetrieb ZSB | 0t | 2000-12-22 | 2000-12-22 |  |  | 201t | anfang nicht früher als 2000-12-22 | Alinhart |
| 97 | 1.7.1.3 | Testbetrieb 1a Fortsetzung | 21t | 2001-01-08 A | 2001-02-05 A |  | 100% | 0t | ende nicht früher als 2001-02-05 | Gbauer |
| 98 | 1.7.2 | **Phase 1b** | 52t | 2001-02-01 A | 2001-04-13 A |  | 100% | 0t | so früh wie möglich | Gbauer |
| 99 | 1.7.2.1 | Besprechung Vorbereitung 1b | 1t | 2001-02-01 A | 2001-02-01 A |  | 100% | 0t | anfang nicht früher als 2001-02-01 | Gbauer |
| 100 | 1.7.2.2 | Connect:Direct Installation/Connectivity Test | 41t | 2001-02-02 A | 2001-03-30 A | 99 | 100% | 0t | anfang nicht früher als 2001-02-02 | Alinhart |
| 101 | 1.7.2.3 | ZNK Ticket Verifizierung | 35t | 2001-02-12 A | 2001-03-30 A |  | 100% | 0t | ende nicht früher als 2001-03-30 | Fwollinger |
| 102 | 1.7.2.4 | Testbetrieb 1b | 10t | 2001-04-02 A | 2001-04-13 A | 101 | 100% | 0t | anfang nicht früher als 2001-04-02 | Gbauer |

Notes:
- 98: Testbetrieb mit IN+Trunk bis in das IS auf Basis AR38 / APS13

| ID | WBS | Task | Duration | Start | Finish | Predecessors | Complete | Total slack | Free slack | Constraint | Text1 |
| --- | --- | --- | --- | --- | --- | --- | --- | --- | --- | --- | --- |
| 103 | 1.7.3 | **Phase 1c** | 100t | 2001-04-16 A | 2001-08-31 |  | 65% | 10t |  | so früh wie möglich | Gbauer |
| 104 | 1.7.3.1 | Testbetrieb 1c | 100t | 2001-04-16 A | 2001-08-31 |  | 65% | 10t | 0t | ende nicht früher als 2001-08-31 | Gbauer |
| 105 | 1.7.4 | **Phase 2** | 75t | 2001-05-21 A | 2001-08-31 | 88 | 53% | 30t |  | so früh wie möglich | Gbauer |
| 106 | 1.7.4.1 | Rollout Sbg./Dreihuf | 1W | 2001-05-21 A | 2001-05-25 A |  | 100% | 0W |  | so früh wie möglich | Alinhart |
| 107 | 1.7.4.2 | Testbetrieb 2 | 14W | 2001-05-28 A | 2001-08-31 | 106 | 50% | 6W |  | anfang nicht früher als 2001-05-28 | Gbauer |
| 108 | 1.7.5 | **Phase 3** | 65t | 2001-06-04 | 2001-08-31 |  |  | 30t |  | so früh wie möglich | Mbenes |
| 109 | 1.7.5.1 | Rollout WienLand/Graz | 1W | 2001-06-04 | 2001-06-08 |  |  | 17W | 0W | anfang nicht früher als 2001-06-04 | Alinhart |
| 110 | 1.7.5.2 | Rollout Innsbr./Klgft. | 1W | 2001-06-11 | 2001-06-15 | 109 |  | 17W |  | so früh wie möglich | Alinhart |
| 111 | 1.7.5.3 | Update/Inbetriebsetzung Graz/Klagenfurt | 2t | 2001-07-19 | 2001-07-20 |  |  | 10t | 0t | ende nicht früher als 2001-07-20 | Alinhart |
| 112 | 1.7.5.4 | Testbetrieb 3 | 6W | 2001-07-23 | 2001-08-31 | 111 |  | 2W | 0W | anfang nicht früher als 2001-07-23 | Alinhart |
| 113 | 1.7.6 | **Überwachter Echtbetrieb** | 20t | 2001-09-03 | 2001-09-28 | 112 |  | 10t |  | so früh wie möglich | Mbenes |
| 114 | 1.7.6.1 | überwachter Echtbetrieb ZNK | 20t | 2001-09-03 | 2001-09-28 | 104 |  | 10t | 0t | ende nicht früher als 2001-09-28 | Alinhart |
| 115 | 1.7.6.2 | überwachter Echtbetrieb Dreihuf,Salzburg | 20t | 2001-09-03 | 2001-09-28 |  |  | 10t | 0t | ende nicht früher als 2001-09-28 | Alinhart |
| 116 | 1.7.6.3 | überwachter Echtbetrieb KL,IB,WL,GR | 20t | 2001-09-03 | 2001-09-28 |  |  | 10t | 0t | ende nicht früher als 2001-09-28 | Alinhart |
| 117 | 1.7.7 | Echtbetrieb aufgenommen | 0t | 2001-09-28 | 2001-09-28 | 116, 115, 114 |  | 10t | 0t | so früh wie möglich | Gbauer |

Notes:
- 103: Testbetrieb mit IN+Trunk bis in das IS auf Basis APS14 / AR40.0
- 105: Testbetrieb mit Standorten ZNK, Salzburg, Dreihuf IN+Trunk+POTS auf Basis APS13+14/AR38+40.1
- 108: Testbetrieb mit Standorten ZNK, Salzburg, Dreihuf,Wien Land, Graz, Klagenfurt, Innsbruck IN+Trunk+POTS auf Basis APS13+14/AR38+40.1
