# Cyclone Launch

Schedule from MS Project MPX, 1998-01-02 to 1998-06-04.
Microsoft

## Calendars

- Standard: Mon-Fri 8:00 AM-12:00 PM, 1:00 PM-5:00 PM; Sat-Sun off.

## Resources

| Resource |
| --- |
| Joe Franklin |
| Rich Anderson |
| Mark Smith |
| Lisa Adams |
| Intern |

## Schedule

| ID | WBS | Task | Type | Duration | Start | Finish | Predecessors | Total slack | Free slack | Constraint | Resources |
| --- | --- | --- | --- | --- | --- | --- | --- | --- | --- | --- | --- |
| 1 | 1 | Marketing Plan distributed | milestone | 0d | 1998-03-17 | 1998-03-17 |  | 0d |  | must start on 1998-03-17 |  |
| 2 | 2 | **Corp Comm** |  | 104d | 1998-01-05 | 1998-05-28 |  | 0d |  |  |  |
| 3 | 2.1 | Corp Comm Kickoff | milestone | 0d | 1998-01-05 | 1998-01-05 |  | 0d |  | must start on 1998-01-05 |  |
| 4 | 2.2 | Comm. Plan delivered | milestone | 0d | 1998-01-23 | 1998-01-23 |  | 0d |  | must start on 1998-01-23 |  |
| 5 | 2.3 | Packaging |  | 12w | 1998-02-13 | 1998-05-07 | 4FS+3w | 0.8w | 0w |  | Joe Franklin |
| 6 | 2.4 | Datasheets |  | 13w | 1998-02-27 | 1998-05-28 | 5SS+2w | 0.8w | 0w |  | Joe Franklin |
| 7 | 2.5 | Reseller kits |  | 11w | 1998-03-13 | 1998-05-28 | 6SS+2w | 0.8w | 0w |  | Joe Franklin |
| 8 | 2.6 | Competitive comparison | milestone | 0d | 1998-04-03 | 1998-04-03 |  | 0d |  | must finish on 1998-04-03 |  |
| 9 | 2.7 | Demo script | milestone | 0d | 1998-04-03 | 1998-04-03 | 8 | 43d |  |  |  |
| 10 | 2.8 | Working Model |  | 6w | 1998-03-20 | 1998-04-30 | 7SS+1w | 4.8w |  |  | Rich Anderson |
| 11 | 3 | **Advertising** |  | 54d | 1998-01-23 | 1998-04-08 |  | 34d |  |  |  |
| 12 | 3.1 | Develop creative briefs |  | 5w | 1998-01-23 | 1998-02-26 | 4 | 11.8w | 0w |  | Mark Smith |
| 13 | 3.2 | Develop concepts |  | 10d | 1998-02-27 | 1998-03-12 | 12 | 59d |  |  | Mark Smith |
| 14 | 3.3 | Creative Concepts | milestone | 0d | 1998-03-11 | 1998-03-11 |  | 0d |  | must finish on 1998-03-11 |  |
| 15 | 3.4 | Ad development |  | 4w | 1998-03-12 | 1998-04-08 | 14 | 8w |  |  |  |
| 16 | 4 | **Public Relations** |  | 95d | 1998-01-19 | 1998-05-29 |  | 0d |  |  |  |
| 17 | 4.1 | PR Kickoff Meeting | milestone | 0d | 1998-01-19 | 1998-01-19 |  | 0d |  | must start on 1998-01-19 |  |
| 18 | 4.2 | Launch planning |  | 18d | 1998-01-19 | 1998-02-11 | 17 | 15d |  |  | Lisa Adams |
| 19 | 4.3 | PR Plan delivered | milestone | 0d | 1998-03-05 | 1998-03-05 | 18 | 0d |  | must start on 1998-03-05 |  |
| 20 | 4.4 | Long-lead time press tour |  | 1w | 1998-03-26 | 1998-04-01 |  | 9w |  | start no earlier than 1998-03-26 |  |
| 21 | 4.5 | Weekly press tour |  | 2d | 1998-05-28 | 1998-05-29 |  | 3d |  | start no earlier than 1998-05-28 |  |
| 22 | 5 | Working model |  | 20w | 1998-01-02 | 1998-05-21 |  | 1.8w |  |  | Intern |
| 23 | 6 | **Beta Test** |  | 91d | 1998-01-15 | 1998-05-21 |  | 9d |  |  |  |
| 24 | 6.1 | Develop Beta List |  | 7w | 1998-01-15 | 1998-03-04 |  | 13w |  | start no earlier than 1998-01-15 |  |
| 25 | 6.2 | Mail Beta Copies | milestone | 0d | 1998-03-26 | 1998-03-26 |  | 0d |  | must finish on 1998-03-26 |  |
| 26 | 6.3 | Provide technical support |  | 8w | 1998-03-27 | 1998-05-21 | 25 | 1.8w | 0w |  |  |
| 27 | 6.4 | Close beta | milestone | 0d | 1998-05-21 | 1998-05-21 | 26 | 9d |  |  |  |

| ID | WBS | Task | Type | Duration | Start | Finish | Predecessors | Total slack | Free slack | Constraint |
| --- | --- | --- | --- | --- | --- | --- | --- | --- | --- | --- |
| 28 | 7 | **Internal Communications** |  | 15d | 1998-03-27 | 1998-04-16 |  | 34d |  |  |
| 29 | 7.1 | Devlp Magazine Article (Oct) |  | 3w | 1998-03-27 | 1998-04-16 | 26SS | 6.8w |  |  |
| 30 | 7.2 | Devlp Reseller Article (Jul/Aug) |  | 3w | 1998-03-27 | 1998-04-16 | 26SS | 6.8w |  |  |
| 31 | 7.3 | Devlp Govt. Article (Sep) |  | 3w | 1998-03-27 | 1998-04-16 | 26SS | 6.8w |  |  |
| 32 | 8 | **Hardware Relationships** |  | 8d | 1998-04-22 | 1998-05-05 |  | 0d |  |  |
| 33 | 8.1 | Meet with Evangelist | milestone | 0d | 1998-04-22 | 1998-04-22 | 25FS+5d | 0d |  | must finish on 1998-04-22 |
| 34 | 8.2 | Meet with Engineering/Tech | milestone | 0d | 1998-05-04 | 1998-05-04 |  | 0d |  | must finish on 1998-05-04 |
| 35 | 8.3 | Meet with Government Evang. | milestone | 0d | 1998-05-05 | 1998-05-05 |  | 0d |  | must start on 1998-05-05 |
| 36 | 8.4 | Meet with Aerospace Evang. | milestone | 0d | 1998-05-05 | 1998-05-05 |  | 0d |  | must start on 1998-05-05 |
| 37 | 9 | **Programs** |  | 65d | 1998-03-05 | 1998-06-04 |  | 0d |  |  |
| 38 | 9.1 | Identify Consultants |  | 8w | 1998-03-26 | 1998-05-20 |  | 2w |  | start no earlier than 1998-03-25 |
| 39 | 9.2 | Mail Eval. to key consultants | milestone | 0d | 1998-06-04 | 1998-06-04 | 38 | 0d |  | must start on 1998-06-04 |
| 40 | 9.3 | Identify key resellers |  | 3w | 1998-03-05 | 1998-03-25 |  | 10w | 9.2w | start no earlier than 1998-03-04 |
| 41 | 9.4 | Reseller visits |  | 2w | 1998-04-20 | 1998-05-01 |  | 4.6w |  | start no earlier than 1998-04-20 |
| 42 | 9.5 | Mail reseller kits to key resellers | milestone | 0d | 1998-05-28 | 1998-05-28 | 7, 40 | 4d |  |  |
| 43 | 10 | Release to manufacturing | milestone | 0d | 1998-05-18 | 1998-05-18 |  | 0d |  | must start on 1998-05-18 |
| 44 | 11 | Manufacture product |  | 2.5w | 1998-05-18 | 1998-06-03 | 43 | 0.1w |  |  |
| 45 | 12 | Project announced | milestone | 0d | 1998-06-03 | 1998-06-03 | 44 | 0d |  | must finish on 1998-06-03 |
